# Proyecto1A

Schedule from MS Project, 2023-12-07 to 2024-04-08, costs in $.

## Calendars

- Estándar: Mon-Fri 09:00-13:00, 15:00-19:00; Sat-Sun off.

## Resources

| Resource | Group | Rate |
| --- | --- | --- |
| Arquitecto | contratado | 85 |
| Ayudante del DP | personal oficina | 40 |
| Carpintero | mantenimiento | 55 |
| Responsable de finanzas | directiva | 60 |
| Técnico informático 1 | técnicos | 45 |
| Técnico informático 2 | técnicos | 35 |
| Electricista | mantenimiento | 30 |
| Empresa constructora | contratado | 80 |
| Jefe de oficina | directiva | 100 |
| Director Proyecto | directiva | 100 |
| Pintor | mantenimiento | 35 |
| Presidente | directiva | 60 |
| Agente inmobiliario | contratado | 75 |
| Vicepresidente | directiva | 100 |

## Schedule

| ID | WBS | Task | Type | Duration | Start | Finish | Predecessors | Total slack | Resources | Work | Cost |
| --- | --- | --- | --- | --- | --- | --- | --- | --- | --- | --- | --- |
| 1 | 1 | **Planificación** |  | 39d | 2023-12-07 | 2024-01-30 |  | 0d |  | 760h | 67,840 |
| 2 | 1.1 | Escribir propuesta |  | 3d | 2023-12-07 | 2023-12-11 |  | 0d | Director Proyecto; Jefe de oficina | 48h | 4,800 |
| 3 | 1.2 | Contratar arquitecto |  | 2d | 2023-12-12 | 2023-12-13 | 2 | 0d | Jefe de oficina; Vicepresidente | 32h | 3,200 |
| 4 | 1.3 | Localizar nueva ubicación |  | 1w | 2023-12-14 | 2023-12-20 | 3 | 0d | Arquitecto; Jefe de oficina; Agente inmobiliario | 120h | 10,400 |
| 5 | 1.4 | Presentar propuesta |  | 2d | 2023-12-21 | 2023-12-22 | 4 | 0d | Director Proyecto; Arquitecto; Presidente; Vicepresidente | 64h | 5,520 |
| 6 | 1.5 | Aprobación de la directiva | milestone | 0d | 2023-12-22 | 2023-12-22 | 5 | 0d | Director Proyecto; Presidente; Vicepresidente |  |  |
| 7 | 1.6 | Negociar nuevo alquiler |  | 4d | 2023-12-25 | 2023-12-28 | 6 | 0d | Vicepresidente; Responsable de finanzas; Agente inmobiliario | 96h | 7,520 |
| 8 | 1.7 | Terminar dibujos |  | 1w | 2023-12-27 | 2024-01-02 | 7FS-2d | 0d | Arquitecto [200%] | 80h | 6,800 |
| 9 | 1.8 | Seleccionar subcontratados |  | 2w | 2024-01-03 | 2024-01-16 | 8 | 0d | Arquitecto; Director Proyecto; Jefe de oficina | 224h | 21,200 |
| 10 | 1.9 | Contratar empresa de mudanzas |  | 4d | 2024-01-11 | 2024-01-16 | 9FF | 0d | Director Proyecto [75%] | 16h | 1,600 |
| 11 | 1.10 | Enviar dibujos |  | 2w | 2024-01-17 | 2024-01-30 | 10 | 0d | Arquitecto | 80h | 6,800 |
| 12 | 1.11 | Permisos recibidos | milestone | 0d | 2024-01-30 | 2024-01-30 | 11 | 0d | Ayudante del DP |  |  |
| 13 | 2 | **Remodelación** |  | 39d | 2024-01-31 | 2024-03-25 |  | 0d |  | 412h | 20,540 |
| 14 | 2.1 | Demolición del espacio existente |  | 3d | 2024-01-31 | 2024-02-02 | 1 | 0d | Empresa constructora | 24h | 1,920 |
| 15 | 2.2 | Levantar tabiques |  | 3d | 2024-02-05 | 2024-02-07 | 14 | 0d | Empresa constructora [150%] | 36h | 2,880 |
| 16 | 2.3 | Instalación eléctrica |  | 6d | 2024-02-08 | 2024-02-15 | 15 | 0d | Electricista | 48h | 1,440 |
| 17 | 2.4 | Instalación de líneas de voz y datos |  | 3d | 2024-02-19 | 2024-02-21 | 16FS+1d | 0d | Electricista | 24h | 720 |
| 18 | 2.5 | Terminar paredes |  | 1w | 2024-02-22 | 2024-02-28 | 17 | 0d | Pintor; Empresa constructora | 80h | 4,600 |
| 19 | 2.6 | Instalar puertas y ventanas |  | 3d | 2024-02-27 | 2024-02-29 | 18FS-2d | 0d | Carpintero | 24h | 1,320 |
| 20 | 2.7 | Pintar |  | 4d | 2024-03-01 | 2024-03-06 | 19 | 0d | Pintor | 32h | 1,120 |
| 21 | 2.8 | Colocar oficinas |  | 3d | 2024-03-07 | 2024-03-11 | 20 | 0d | Carpintero | 24h | 1,320 |
| 22 | 2.9 | Colocar sala del servidor |  | 3d | 2024-03-07 | 2024-03-11 | 21SS | 0d | Técnico informático 1 | 24h | 1,080 |
| 23 | 2.10 | Ultimas reparaciones |  | 1w | 2024-03-12 | 2024-03-18 | 21, 22 | 0d | Carpintero [50%]; Electricista [50%] | 40h | 1,700 |
| 24 | 2.11 | Probar sistemas |  | 2d | 2024-03-19 | 2024-03-20 | 23 | 1d | Electricista | 16h | 480 |
| 25 | 2.12 | Revisión de acabado |  | 3d | 2024-03-19 | 2024-03-21 | 23, 24FF | 0d | Carpintero | 24h | 1,320 |
| 26 | 2.13 | Limpieza final |  | 2d | 2024-03-22 | 2024-03-25 | 25 | 0d | Ayudante del DP | 16h | 640 |
| 27 | 2.14 | Remodelación terminada | milestone | 0d | 2024-03-25 | 2024-03-25 | 26 | 0d | Director Proyecto; Empresa constructora |  |  |

| ID | WBS | Task | Type | Duration | Start | Finish | Predecessors | Total slack | Free slack | Resources | Work | Cost |
| --- | --- | --- | --- | --- | --- | --- | --- | --- | --- | --- | --- | --- |
| 28 | 3 | **Traslado** |  | 9.5d | 2024-03-26 | 2024-04-08 | 13 | 0d |  |  | 166h | 8,090 |
| 29 | 3.1 | **Oficinas** |  | 6.5d | 2024-03-26 | 2024-04-03 |  | 0d |  |  | 100h | 5,140 |
| 30 | 3.1.1 | Desconectar computadoras/equipos |  | 2d | 2024-03-26 | 2024-03-27 |  | 0d |  | Técnico informático 1 | 16h | 720 |
| 31 | 3.1.2 | Desmontar mobiliario |  | 2d | 2024-03-27 | 2024-03-28 | 30FS-1d | 3d | 0d | Ayudante del DP; Carpintero | 32h | 1,520 |
| 32 | 3.1.3 | Trasladar mobiliario/equipo/cajas |  | 4h | 2024-03-29 | 2024-03-29 | 31 | 3d | 0d | Ayudante del DP; Carpintero; Empresa constructora | 12h | 700 |
| 33 | 3.1.4 | Montar mobiliario |  | 2d | 2024-03-29 | 2024-04-02 | 32 | 3d | 0d | Ayudante del DP; Empresa constructora | 32h | 1,920 |
| 34 | 3.1.5 | Conectar computadoras/equipos |  | 2d | 2024-04-01 | 2024-04-03 | 33FS-1d | 3d | 0d | Técnico informático 2 [50%] | 8h | 280 |
| 35 | 3.1.6 | Oficinas terminadas | milestone | 0d | 2024-04-03 | 2024-04-03 | 34 | 3d |  | Director Proyecto; Empresa constructora |  |  |
| 36 | 3.2 | **Sala del servidor** |  | 7.5d | 2024-03-28 | 2024-04-08 |  | 0d |  |  | 66h | 2,950 |
| 37 | 3.2.1 | Hacer copia de seguridad del servidor |  | 2d | 2024-03-28 | 2024-03-29 | 30 | 0d |  | Técnico informático 1 | 16h | 720 |
| 38 | 3.2.2 | Desconectar servidor |  | 2d | 2024-04-01 | 2024-04-02 | 37 | 0d |  | Técnico informático 1 | 16h | 720 |
| 39 | 3.2.3 | Trasladar servidor |  | 4h | 2024-04-03 | 2024-04-03 | 38 | 0d |  | Técnico informático 2 [50%] | 2h | 70 |
| 40 | 3.2.4 | Conectar servidor |  | 2d | 2024-04-03 | 2024-04-05 | 39 | 0d |  | Técnico informático 1 | 16h | 720 |
| 41 | 3.2.5 | Probar servidor |  | 1d | 2024-04-05 | 2024-04-08 | 40 | 0d |  | Técnico informático 1 [200%] | 16h | 720 |
| 42 | 3.2.6 | Sala del servidor terminada | milestone | 0d | 2024-04-08 | 2024-04-08 | 41 | 0d |  | Director Proyecto; Técnico informático 1; Técnico informático 2 |  |  |
| 43 | 4 | Traslado terminado | milestone | 0d | 2024-04-08 | 2024-04-08 | 28, 35 | 0d |  | Director Proyecto; Empresa constructora |  |  |
